# Reunión de Asociados

Schedule from MS Project, 2016-06-01 to 2016-07-14, costs in €.
Reunión de Asociados

## Calendars

- Reunion Asociados: Mon 13:00-17:00; Tue-Thu 08:00-12:00; Fri 09:30-13:30; Sat-Sun off. Exceptions (off unless hours are given): 2016-07-04 (4 de Julio).

## Resources

| Resource | Rate |
| --- | --- |
| Auxiliar | 29 |
| Jefe de oficina | 21.63 |
| Personal de oficina | 10 |
| Presidente | 40.87 |
| Desplazamiento |  |
| Imprimir |  |

## Schedule

| ID | WBS | Task | Type | Duration | Start | Finish | Predecessors | Total slack | Free slack | Resources | Work | Cost |
| --- | --- | --- | --- | --- | --- | --- | --- | --- | --- | --- | --- | --- |
| 1 | 1 | **Planificación preliminar** |  | 5.5d | 2016-06-01 | 2016-06-15 |  | 0d |  |  | 64h | 2,999.23 |
| 2 | 1.1 | Programar fecha de la conferencia |  | 2d | 2016-06-01 | 2016-06-06 |  | 0d |  | Jefe de oficina; Presidente | 32h | 1,000 |
| 3 | 1.2 | Reservar centro de conferencias |  | 1d | 2016-06-07 | 2016-06-08 | 2 | 0d |  | Personal de oficina | 8h | 1,280 |
| 4 | 1.3 | Buscar Conferenciante |  | 3d | 2016-06-08 | 2016-06-15 | 3FS-0.5d | 0d |  | Jefe de oficina; Desplazamiento [0.1%] | 24h | 719.23 |
| 5 | 1.4 | Planificación preliminar completa | milestone | 0d | 2016-06-15 | 2016-06-15 | 4 | 0d |  |  |  |  |
| 6 | 2 | **Carta de notificación** |  | 5d | 2016-06-16 | 2016-06-29 | 1 | 5d |  |  | 25h | 1,147 |
| 7 | 2.1 | Ordenar lista de envío |  | 1h | 2016-06-16 | 2016-06-16 |  | 5d | 0d | Personal de oficina | 1h | 15 |
| 8 | 2.2 | Preparar Carta |  | 1d | 2016-06-16 | 2016-06-17 | 7SS | 5d | 0d | Auxiliar | 8h | 232 |
| 9 | 2.3 | Revisar carta |  | 1d | 2016-06-20 | 2016-06-21 | 8 | 5d | 0d | Jefe de oficina | 8h | 173.08 |
| 10 | 2.4 | Aprobar carta |  | 1d | 2016-06-22 | 2016-06-23 | 9 | 5d | 0d | Presidente | 8h | 326.92 |
| 11 | 2.5 | Imprimir carta |  | 2d | 2016-06-24 | 2016-06-29 | 10 | 5d | 0d |  |  |  |
| 12 | 2.6 | Enviar carta | milestone | 0d | 2016-06-29 | 2016-06-29 | 11 | 5d |  |  |  | 400 |
| 13 | 3 | **Detalles de la reunión** |  | 8d | 2016-06-16 | 2016-07-08 | 1 | 0d |  |  | 48h | 1,195 |
| 14 | 3.1 | Preparar menú con empresa catering |  | 3d | 2016-06-16 | 2016-06-23 |  | 0d |  | Auxiliar | 24h | 696 |
| 15 | 3.2 | Preparar salas de reunión del comité |  | 1d | 2016-06-24 | 2016-06-27 | 14 | 0d |  | Personal de oficina | 8h | 80 |
| 16 | 3.3 | Preparar equipamiento necesario |  | 2d | 2016-06-22 | 2016-06-27 | 15FF | 0d |  | Auxiliar | 16h | 384 |
| 17 | 3.4 | Preparar programa |  | 3d | 2016-06-28 | 2016-07-06 | 16 | 0d |  |  |  |  |
| 18 | 3.5 | Imprimir programa |  | 1d | 2016-07-07 | 2016-07-08 | 17 | 0d |  | Imprimir [0.1%] |  | 35 |
| 19 | 4 | Celebración de la reunión | milestone | 0d | 2016-07-14 | 2016-07-14 | 13FS+2d | 0d |  |  |  |  |
