# Construcción de unifamiliar 4.6

Schedule from MS Project, 2016-02-01 to 2016-09-09, status date 2016-04-30, costs in €, A marks actual dates.
Microsoft

## Calendars

- Estándar: Mon-Fri 09:00-13:00, 15:00-19:00; Sat-Sun off.

## Resources

| Resource | Rate |
| --- | --- |
| Ayuntamiento |  |
| Camiones de hormigón |  |
| Christos | 1000 |
| Cliente |  |
| Contrata limpieza | 45 |
| Hormigón | 30 |
| Jacinto | 70 |
| Matías | 100 |
| Paloma | 60 |
| Ronnie | 60 |
| Tec1 | 30 |
| ERC | 48.08 |

## Schedule

| ID | WBS | Task | Type | Duration | Start | Finish | Predecessors | Complete | Remaining | Baseline start | Baseline finish | Baseline duration | Total slack | Free slack | Resources | Work | Actual work | Cost | Baseline cost | Actual cost |
| --- | --- | --- | --- | --- | --- | --- | --- | --- | --- | --- | --- | --- | --- | --- | --- | --- | --- | --- | --- | --- |
| 1 | 1 | Inicio de Proyecto | milestone | 0d | 2016-02-01 07:00 A | 2016-02-01 07:00 A |  | 100% |  | 2016-02-01 07:00 | 2016-02-01 07:00 |  |  |  | Christos |  |  |  |  |  |
| 2 | 2 | **Planificación** |  | 43d | 2016-02-02 19:00 A | 2016-04-01 19:00 | 1FS+2d | 30% | 30d | 2016-02-02 19:00 | 2016-04-05 19:00 | 45d | 0d |  |  | 528h | 208h | 36,480 | 40,000 | 17,680 |
| 3 | 2.1 | Inicio Fase2 | milestone | 0d | 2016-02-02 19:00 A | 2016-02-02 19:00 A |  | 100% |  | 2016-02-02 19:00 | 2016-02-02 19:00 |  |  |  |  |  |  |  |  |  |
| 4 | 2.2 | Diseño |  | 17d | 2016-02-03 09:00 A | 2016-02-25 19:00 | 3 | 76% | 4d | 2016-02-03 09:00 | 2016-03-01 19:00 | 20d | 0d |  | Jacinto; Matías | 272h | 208h | 23,120 | 27,200 | 17,680 |
| 5 | 2.3 | Modificaciones del cliente |  | 6d | 2016-02-26 09:00 | 2016-03-04 19:00 | 4 |  |  | 2016-03-02 09:00 | 2016-03-08 19:00 | 5d | 0d |  | Cliente; Jacinto | 96h |  | 3,360 | 2,800 |  |
| 6 | 2.4 | Permisos de construcción |  | 20d | 2016-03-07 09:00 | 2016-04-01 19:00 | 5 |  |  | 2016-03-09 09:00 | 2016-04-05 19:00 | 20d | 0d |  | Ayuntamiento | 160h |  |  |  |  |
| 7 | 2.5 | Fin Fase2 | milestone | 0d | 2016-04-01 19:00 | 2016-04-01 19:00 | 6 |  |  | 2016-04-05 19:00 | 2016-04-05 19:00 |  | 0d |  |  |  |  | 10,000 | 10,000 |  |
| 8 | 3 | **Cimentación** |  | 23d | 2016-04-01 19:00 | 2016-05-04 19:00 | 2 |  |  | 2016-04-05 19:00 | 2016-05-06 19:00 | 23d | 0d |  |  | 176h |  | 7,190 | 7,190 |  |
| 9 | 3.1 | Inicio Fase3 | milestone | 0d | 2016-04-01 19:00 | 2016-04-01 19:00 |  |  |  | 2016-04-05 19:00 | 2016-04-05 19:00 |  | 0d |  |  |  |  |  |  |  |
| 10 | 3.2 | Limpieza del terreno |  | 6d | 2016-04-04 09:00 | 2016-04-11 19:00 | 9 |  |  | 2016-04-06 09:00 | 2016-04-13 19:00 | 6d | 0d |  | Contrata limpieza | 48h |  | 2,160 | 2,160 |  |
| 11 | 3.3 | Preparación del terreno |  | 10d | 2016-04-12 09:00 | 2016-04-25 19:00 | 10 |  |  | 2016-04-14 09:00 | 2016-04-27 19:00 | 10d | 0d |  | Tec1 | 80h |  | 2,400 | 2,400 |  |
| 12 | 3.4 | Zanjas |  | 2d | 2016-04-26 09:00 | 2016-04-27 19:00 | 11 |  |  | 2016-04-28 09:00 | 2016-04-29 19:00 | 2d | 0d |  | Tec1 | 16h |  | 480 | 480 |  |
| 13 | 3.5 | Hormigonar |  | 1d | 2016-04-28 09:00 | 2016-04-28 19:00 | 12 |  |  | 2016-05-02 09:00 | 2016-05-02 19:00 | 1d | 0d |  | Camiones de hormigón [0.1%]; Hormigón |  |  | 230 | 230 |  |
| 14 | 3.6 | Fraguar |  | 4d | 2016-04-29 09:00 | 2016-05-04 19:00 | 13 |  |  | 2016-05-03 09:00 | 2016-05-06 19:00 | 4d | 0d |  | Ronnie | 32h |  | 1,920 | 1,920 |  |
| 15 | 3.7 | Fin Fase3 | milestone | 0d | 2016-05-04 19:00 | 2016-05-04 19:00 | 14 |  |  | 2016-05-06 19:00 | 2016-05-06 19:00 |  | 0d |  |  |  |  |  |  |  |
| 16 | 4 | **Estructuración** |  | 47d | 2016-05-04 19:00 | 2016-07-08 19:00 | 8 |  |  | 2016-05-06 19:00 | 2016-07-12 19:00 | 47d | 0d |  |  | 520h |  | 20,400 | 20,400 |  |
| 17 | 4.1 | Inicio Fase4 | milestone | 0d | 2016-05-04 19:00 | 2016-05-04 19:00 |  |  |  | 2016-05-06 19:00 | 2016-05-06 19:00 |  | 0d |  |  |  |  |  |  |  |
| 18 | 4.2 | Muros de carga |  | 20d | 2016-05-05 09:00 | 2016-06-01 19:00 | 17 |  |  | 2016-05-09 09:00 | 2016-06-03 19:00 | 20d | 0d |  | Paloma; Tec1 | 320h |  | 14,400 | 14,400 |  |
| 19 | 4.3 | Columnas |  | 10d | 2016-06-02 09:00 | 2016-06-15 19:00 | 18 |  |  | 2016-06-06 09:00 | 2016-06-17 19:00 | 10d | 0d |  | Tec1 | 80h |  | 2,400 | 2,400 |  |
| 20 | 4.4 | Tabiques |  | 15d | 2016-06-20 09:00 | 2016-07-08 19:00 | 19FS+2d |  |  | 2016-06-22 09:00 | 2016-07-12 19:00 | 15d | 0d |  | Tec1 | 120h |  | 3,600 | 3,600 |  |
| 21 | 4.5 | Fin Fase4 | milestone | 0d | 2016-07-08 19:00 | 2016-07-08 19:00 | 20 |  |  | 2016-07-12 19:00 | 2016-07-12 19:00 |  | 0d |  |  |  |  |  |  |  |
| 22 | 5 | **Servicios** |  | 30d | 2016-07-08 19:00 | 2016-08-19 19:00 | 16 |  |  | 2016-07-12 19:00 | 2016-08-23 19:00 | 30d | 0d |  |  | 304h |  | 9,120 | 9,120 |  |
| 23 | 5.1 | Inicio Fase5 | milestone | 0d | 2016-07-08 19:00 | 2016-07-08 19:00 |  |  |  | 2016-07-12 19:00 | 2016-07-12 19:00 |  | 22d | 0d |  |  |  |  |  |  |
| 24 | 5.2 | **Agua** |  | 8d | 2016-07-08 19:00 | 2016-07-20 19:00 | 23 |  |  | 2016-07-12 19:00 | 2016-07-22 19:00 | 8d | 22d | 0d |  | 64h |  | 1,920 | 1,920 |  |
| 25 | 5.2.1 | Inicio 5.2 | milestone | 0d | 2016-07-08 19:00 | 2016-07-08 19:00 |  |  |  | 2016-07-12 19:00 | 2016-07-12 19:00 |  | 22d | 0d |  |  |  |  |  |  |
| 26 | 5.2.2 | Plomeria |  | 4d | 2016-07-11 09:00 | 2016-07-14 19:00 | 25 |  |  | 2016-07-13 09:00 | 2016-07-18 19:00 | 4d | 22d | 0d | Tec1 | 32h |  | 960 | 960 |  |
| 27 | 5.2.3 | Lavatorios |  | 1d | 2016-07-15 09:00 | 2016-07-15 19:00 | 26 |  |  | 2016-07-19 09:00 | 2016-07-19 19:00 | 1d | 22d | 0d | Tec1 | 8h |  | 240 | 240 |  |
| 28 | 5.2.4 | Inodoros |  | 2d | 2016-07-18 09:00 | 2016-07-19 19:00 | 27 |  |  | 2016-07-20 09:00 | 2016-07-21 19:00 | 2d | 22d | 0d | Tec1 | 16h |  | 480 | 480 |  |
| 29 | 5.2.5 | Bañeras |  | 1d | 2016-07-20 09:00 | 2016-07-20 19:00 | 28 |  |  | 2016-07-22 09:00 | 2016-07-22 19:00 | 1d | 22d | 0d | Tec1 | 8h |  | 240 | 240 |  |
| 30 | 5.2.6 | Fin 5.2 | milestone | 0d | 2016-07-20 19:00 | 2016-07-20 19:00 | 29 |  |  | 2016-07-22 19:00 | 2016-07-22 19:00 |  | 22d |  |  |  |  |  |  |  |

| ID | WBS | Task | Type | Duration | Start | Finish | Predecessors | Baseline start | Baseline finish | Baseline duration | Total slack | Resources | Work | Cost | Baseline cost |
| --- | --- | --- | --- | --- | --- | --- | --- | --- | --- | --- | --- | --- | --- | --- | --- |
| 31 | 5.3 | **Luz** |  | 8d | 2016-07-08 19:00 | 2016-07-20 19:00 | 24SS | 2016-07-12 19:00 | 2016-07-22 19:00 | 8d | 0d |  | 64h | 1,920 | 1,920 |
| 32 | 5.3.1 | Inicio 5.3 | milestone | 0d | 2016-07-08 19:00 | 2016-07-08 19:00 |  | 2016-07-12 19:00 | 2016-07-12 19:00 |  | 0d |  |  |  |  |
| 33 | 5.3.2 | Cableado |  | 3d | 2016-07-11 09:00 | 2016-07-13 19:00 | 32 | 2016-07-13 09:00 | 2016-07-15 19:00 | 3d | 0d | Tec1 | 24h | 720 | 720 |
| 34 | 5.3.3 | Interruptores |  | 2d | 2016-07-14 09:00 | 2016-07-15 19:00 | 33 | 2016-07-18 09:00 | 2016-07-19 19:00 | 2d | 0d | Tec1 | 16h | 480 | 480 |
| 35 | 5.3.4 | Tomas |  | 2d | 2016-07-18 09:00 | 2016-07-19 19:00 | 34 | 2016-07-20 09:00 | 2016-07-21 19:00 | 2d | 0d | Tec1 | 16h | 480 | 480 |
| 36 | 5.3.5 | Panel |  | 1d | 2016-07-20 09:00 | 2016-07-20 19:00 | 35 | 2016-07-22 09:00 | 2016-07-22 19:00 | 1d | 0d | Tec1 | 8h | 240 | 240 |
| 37 | 5.3.6 | Fin 5.3 | milestone | 0d | 2016-07-20 19:00 | 2016-07-20 19:00 | 36 | 2016-07-22 19:00 | 2016-07-22 19:00 |  | 0d |  |  |  |  |
| 38 | 5.4 | **Paredes** |  | 22d | 2016-07-20 19:00 | 2016-08-19 19:00 | 31 | 2016-07-22 19:00 | 2016-08-23 19:00 | 22d | 0d |  | 176h | 5,280 | 5,280 |
| 39 | 5.4.1 | Inicio 5.4 | milestone | 0d | 2016-07-20 19:00 | 2016-07-20 19:00 |  | 2016-07-22 19:00 | 2016-07-22 19:00 |  | 0d |  |  |  |  |
| 40 | 5.4.2 | Lucir |  | 4d | 2016-07-21 09:00 | 2016-07-26 19:00 | 39 | 2016-07-25 09:00 | 2016-07-28 19:00 | 4d | 0d | Tec1 | 32h | 960 | 960 |
| 41 | 5.4.3 | Azulejos |  | 5d | 2016-07-27 09:00 | 2016-08-02 19:00 | 40 | 2016-07-29 09:00 | 2016-08-04 19:00 | 5d | 0d | Tec1 | 40h | 1,200 | 1,200 |
| 42 | 5.4.4 | Suelos |  | 7d | 2016-08-03 09:00 | 2016-08-11 19:00 | 41 | 2016-08-05 09:00 | 2016-08-15 19:00 | 7d | 0d | Tec1 | 56h | 1,680 | 1,680 |
| 43 | 5.4.5 | Aislante |  | 4d | 2016-08-12 09:00 | 2016-08-17 19:00 | 42 | 2016-08-16 09:00 | 2016-08-19 19:00 | 4d | 0d | Tec1 | 32h | 960 | 960 |
| 44 | 5.4.6 | Pintura |  | 2d | 2016-08-18 09:00 | 2016-08-19 19:00 | 43 | 2016-08-22 09:00 | 2016-08-23 19:00 | 2d | 0d | Tec1 | 16h | 480 | 480 |
| 45 | 5.4.7 | Fin 5.4 | milestone | 0d | 2016-08-19 19:00 | 2016-08-19 19:00 | 44 | 2016-08-23 19:00 | 2016-08-23 19:00 |  | 0d |  |  |  |  |
| 46 | 5.5 | Fin Fase5 | milestone | 0d | 2016-08-19 19:00 | 2016-08-19 19:00 | 38 | 2016-08-23 19:00 | 2016-08-23 19:00 |  | 0d |  |  |  |  |
| 47 | 6 | **Exteriores** |  | 12d | 2016-08-19 19:00 | 2016-09-06 19:00 | 22 | 2016-08-23 19:00 | 2016-09-08 19:00 | 12d | 0d |  | 120h | 3,600 | 3,600 |
| 48 | 6.1 | Inicio Fase6 | milestone | 0d | 2016-08-19 19:00 | 2016-08-19 19:00 |  | 2016-08-23 19:00 | 2016-08-23 19:00 |  | 0d |  |  |  |  |
| 49 | 6.2 | Revestimientos |  | 2d | 2016-08-22 09:00 | 2016-08-23 19:00 | 48 | 2016-08-24 09:00 | 2016-08-25 19:00 | 2d | 0d | Tec1 | 16h | 480 | 480 |
| 50 | 6.3 | Cera |  | 1d | 2016-08-24 09:00 | 2016-08-24 19:00 | 49 | 2016-08-26 09:00 | 2016-08-26 19:00 | 1d | 0d | Tec1 | 8h | 240 | 240 |
| 51 | 6.4 | Tejado |  | 5d | 2016-08-25 09:00 | 2016-08-31 19:00 | 50 | 2016-08-29 09:00 | 2016-09-02 19:00 | 5d | 0d | Tec1 | 40h | 1,200 | 1,200 |
| 52 | 6.5 | Puertas |  | 4d | 2016-09-01 09:00 | 2016-09-06 19:00 | 51 | 2016-09-05 09:00 | 2016-09-08 19:00 | 4d | 0d | Tec1 | 32h | 960 | 960 |
| 53 | 6.6 | Ventanas |  | 3d | 2016-09-02 09:00 | 2016-09-06 19:00 | 52FF | 2016-09-06 09:00 | 2016-09-08 19:00 | 3d | 0d | Tec1 | 24h | 720 | 720 |
| 54 | 6.7 | Fin Fase6 | milestone | 0d | 2016-09-06 19:00 | 2016-09-06 19:00 | 53 | 2016-09-08 19:00 | 2016-09-08 19:00 |  | 0d |  |  |  |  |

| ID | WBS | Task | Type | Duration | Start | Finish | Predecessors | Complete | Remaining | Baseline start | Baseline finish | Baseline duration | Total slack | Constraint | Resources | Work | Actual work | Cost | Baseline cost | Actual cost |
| --- | --- | --- | --- | --- | --- | --- | --- | --- | --- | --- | --- | --- | --- | --- | --- | --- | --- | --- | --- | --- |
| 55 | 7 | **Limpieza** |  | 3d | 2016-09-06 19:00 | 2016-09-09 19:00 | 47 |  |  | 2016-09-08 19:00 | 2016-09-13 19:00 | 3d | 0d |  |  | 24h |  | 1,153.85 | 1,080 |  |
| 56 | 7.1 | Inicio Fase7 | milestone | 0d | 2016-09-06 19:00 | 2016-09-06 19:00 |  |  |  | 2016-09-08 19:00 | 2016-09-08 19:00 |  | 0d |  |  |  |  |  |  |  |
| 57 | 7.2 | Interiores |  | 1d | 2016-09-07 09:00 | 2016-09-07 19:00 | 56 |  |  | 2016-09-09 09:00 | 2016-09-09 19:00 | 1d | 0d |  | ERC | 8h |  | 384.62 | 360 |  |
| 58 | 7.3 | Fachada |  | 1d | 2016-09-08 09:00 | 2016-09-08 19:00 | 57 |  |  | 2016-09-12 09:00 | 2016-09-12 19:00 | 1d | 0d |  | ERC | 8h |  | 384.62 | 360 |  |
| 59 | 7.4 | Parcela |  | 1d | 2016-09-09 09:00 | 2016-09-09 19:00 | 58 |  |  | 2016-09-13 09:00 | 2016-09-13 19:00 | 1d | 0d |  | ERC | 8h |  | 384.62 | 360 |  |
| 60 | 7.5 | Fin Fase7 | milestone | 0d | 2016-09-09 19:00 | 2016-09-09 19:00 | 59 |  |  | 2016-09-13 19:00 | 2016-09-13 19:00 |  | 0d |  |  |  |  |  |  |  |
| 61 | 8 | Fin de Proyecto | milestone | 0d | 2016-09-09 19:00 | 2016-09-09 19:00 | 55 |  |  | 2016-09-13 19:00 | 2016-09-13 19:00 |  | 0d |  |  |  |  |  |  |  |
| 62 | 9 | **Seguimientos** |  | 159d | 2016-02-01 07:00 A | 2016-09-09 07:30 |  | 9% | 144.18d | 2016-02-01 07:00 | 2016-09-13 07:30 | 161d | 0d |  |  | 3712h | 375.12h | 371,200 | 376,800 | 37,511.5 |
| 63 | 9.1 | **Revisión en área de trabajo** |  | 159d | 2016-02-01 07:00 A | 2016-09-09 07:30 |  | 9% | 145.39d | 2016-02-01 07:00 | 2016-09-13 07:30 | 161d | 0d |  | Matías | 1272h | 108.86h | 127,200 | 128,800 | 10,886.5 |
| 64 | 9.1.1 | 1 | manual | 30min | 2016-02-01 07:00 A | 2016-02-01 07:30 A |  | 100% |  | 2016-02-01 07:00 | 2016-02-01 07:30 | 30min |  | start no earlier than 2016-02-01 07:00 |  |  |  |  |  |  |
| 65 | 9.1.2 | 2 | manual | 30min | 2016-02-02 07:00 A | 2016-02-02 07:30 A |  | 100% |  | 2016-02-02 07:00 | 2016-02-02 07:30 | 30min |  | start no earlier than 2016-02-02 07:00 |  |  |  |  |  |  |
| 66 | 9.1.3 | 3 | manual | 30min | 2016-02-03 07:00 A | 2016-02-03 07:30 A |  | 100% |  | 2016-02-03 07:00 | 2016-02-03 07:30 | 30min |  | start no earlier than 2016-02-03 07:00 |  |  |  |  |  |  |
| 67 | 9.1.4 | 4 | manual | 30min | 2016-02-04 07:00 A | 2016-02-04 07:30 A |  | 100% |  | 2016-02-04 07:00 | 2016-02-04 07:30 | 30min |  | start no earlier than 2016-02-04 07:00 |  |  |  |  |  |  |
| 68 | 9.1.5 | 5 | manual | 30min | 2016-02-05 07:00 A | 2016-02-05 07:30 A |  | 100% |  | 2016-02-05 07:00 | 2016-02-05 07:30 | 30min |  | start no earlier than 2016-02-05 07:00 |  |  |  |  |  |  |
| 69 | 9.1.6 | 6 | manual | 30min | 2016-02-06 07:00 A | 2016-02-06 07:30 A |  | 100% |  | 2016-02-06 07:00 | 2016-02-06 07:30 | 30min |  | start no earlier than 2016-02-06 07:00 |  |  |  |  |  |  |
| 70 | 9.1.7 | 7 | manual | 30min | 2016-02-07 07:00 A | 2016-02-07 07:30 A |  | 100% |  | 2016-02-07 07:00 | 2016-02-07 07:30 | 30min |  | start no earlier than 2016-02-07 07:00 |  |  |  |  |  |  |
| 71 | 9.1.8 | 8 | manual | 30min | 2016-02-08 07:00 A | 2016-02-08 07:30 A |  | 100% |  | 2016-02-08 07:00 | 2016-02-08 07:30 | 30min |  | start no earlier than 2016-02-08 07:00 |  |  |  |  |  |  |
| 72 | 9.1.9 | 9 | manual | 30min | 2016-02-09 07:00 A | 2016-02-09 07:30 A |  | 100% |  | 2016-02-09 07:00 | 2016-02-09 07:30 | 30min |  | start no earlier than 2016-02-09 07:00 |  |  |  |  |  |  |
| 73 | 9.1.10 | 10 | manual | 30min | 2016-02-10 07:00 A | 2016-02-10 07:30 A |  | 100% |  | 2016-02-10 07:00 | 2016-02-10 07:30 | 30min |  | start no earlier than 2016-02-10 07:00 |  |  |  |  |  |  |
| 74 | 9.1.11 | 11 | manual | 30min | 2016-02-11 07:00 A | 2016-02-11 07:30 A |  | 100% |  | 2016-02-11 07:00 | 2016-02-11 07:30 | 30min |  | start no earlier than 2016-02-11 07:00 |  |  |  |  |  |  |
| 75 | 9.1.12 | 12 | manual | 30min | 2016-02-12 07:00 A | 2016-02-12 07:30 A |  | 100% |  | 2016-02-12 07:00 | 2016-02-12 07:30 | 30min |  | start no earlier than 2016-02-12 07:00 |  |  |  |  |  |  |
| 76 | 9.1.13 | 13 | manual | 30min | 2016-02-13 07:00 A | 2016-02-13 07:30 A |  | 100% |  | 2016-02-13 07:00 | 2016-02-13 07:30 | 30min |  | start no earlier than 2016-02-13 07:00 |  |  |  |  |  |  |
| 77 | 9.1.14 | 14 | manual | 30min | 2016-02-14 07:00 A | 2016-02-14 07:30 A |  | 100% |  | 2016-02-14 07:00 | 2016-02-14 07:30 | 30min |  | start no earlier than 2016-02-14 07:00 |  |  |  |  |  |  |
| 78 | 9.1.15 | 15 | manual | 30min | 2016-02-15 07:00 A | 2016-02-15 07:30 A |  | 100% |  | 2016-02-15 07:00 | 2016-02-15 07:30 | 30min |  | start no earlier than 2016-02-15 07:00 |  |  |  |  |  |  |
| 79 | 9.1.16 | 16 | manual | 30min | 2016-02-16 07:00 A | 2016-02-16 07:30 A |  | 100% |  | 2016-02-16 07:00 | 2016-02-16 07:30 | 30min |  | start no earlier than 2016-02-16 07:00 |  |  |  |  |  |  |
| 80 | 9.1.17 | 17 | manual | 30min | 2016-02-17 07:00 A | 2016-02-17 07:30 A |  | 100% |  | 2016-02-17 07:00 | 2016-02-17 07:30 | 30min |  | start no earlier than 2016-02-17 07:00 |  |  |  |  |  |  |
| 81 | 9.1.18 | 18 | manual | 30min | 2016-02-18 07:00 A | 2016-02-18 07:30 A |  | 100% |  | 2016-02-18 07:00 | 2016-02-18 07:30 | 30min |  | start no earlier than 2016-02-18 07:00 |  |  |  |  |  |  |
| 82 | 9.1.19 | 19 | manual | 30min | 2016-02-19 07:00 A | 2016-02-19 07:30 A |  | 100% |  | 2016-02-19 07:00 | 2016-02-19 07:30 | 30min |  | start no earlier than 2016-02-19 07:00 |  |  |  |  |  |  |
| 83 | 9.1.20 | 20 | manual | 30min | 2016-02-20 07:00 | 2016-02-20 07:30 |  |  |  | 2016-02-20 07:00 | 2016-02-20 07:30 | 30min |  | start no earlier than 2016-02-20 07:00 |  |  |  |  |  |  |
| 84 | 9.1.21 | 21 | manual | 30min | 2016-02-21 07:00 | 2016-02-21 07:30 |  |  |  | 2016-02-21 07:00 | 2016-02-21 07:30 | 30min |  | start no earlier than 2016-02-21 07:00 |  |  |  |  |  |  |
| 85 | 9.1.22 | 22 | manual | 30min | 2016-02-22 07:00 | 2016-02-22 07:30 |  |  |  | 2016-02-22 07:00 | 2016-02-22 07:30 | 30min |  | start no earlier than 2016-02-22 07:00 |  |  |  |  |  |  |
| 86 | 9.1.23 | 23 | manual | 30min | 2016-02-23 07:00 | 2016-02-23 07:30 |  |  |  | 2016-02-23 07:00 | 2016-02-23 07:30 | 30min |  | start no earlier than 2016-02-23 07:00 |  |  |  |  |  |  |
| 87 | 9.1.24 | 24 | manual | 30min | 2016-02-24 07:00 | 2016-02-24 07:30 |  |  |  | 2016-02-24 07:00 | 2016-02-24 07:30 | 30min |  | start no earlier than 2016-02-24 07:00 |  |  |  |  |  |  |
| 88 | 9.1.25 | 25 | manual | 30min | 2016-02-25 07:00 | 2016-02-25 07:30 |  |  |  | 2016-02-25 07:00 | 2016-02-25 07:30 | 30min |  | start no earlier than 2016-02-25 07:00 |  |  |  |  |  |  |
| 89 | 9.1.26 | 26 | manual | 30min | 2016-02-26 07:00 | 2016-02-26 07:30 |  |  |  | 2016-02-26 07:00 | 2016-02-26 07:30 | 30min |  | start no earlier than 2016-02-26 07:00 |  |  |  |  |  |  |
| 90 | 9.1.27 | 27 | manual | 30min | 2016-02-27 07:00 | 2016-02-27 07:30 |  |  |  | 2016-02-27 07:00 | 2016-02-27 07:30 | 30min |  | start no earlier than 2016-02-27 07:00 |  |  |  |  |  |  |
| 91 | 9.1.28 | 28 | manual | 30min | 2016-02-28 07:00 | 2016-02-28 07:30 |  |  |  | 2016-02-28 07:00 | 2016-02-28 07:30 | 30min |  | start no earlier than 2016-02-28 07:00 |  |  |  |  |  |  |
| 92 | 9.1.29 | 29 | manual | 30min | 2016-02-29 07:00 | 2016-02-29 07:30 |  |  |  | 2016-02-29 07:00 | 2016-02-29 07:30 | 30min |  | start no earlier than 2016-02-29 07:00 |  |  |  |  |  |  |
| 93 | 9.1.30 | 30 | manual | 30min | 2016-03-01 07:00 | 2016-03-01 07:30 |  |  |  | 2016-03-01 07:00 | 2016-03-01 07:30 | 30min |  | start no earlier than 2016-03-01 07:00 |  |  |  |  |  |  |
| 94 | 9.1.31 | 31 | manual | 30min | 2016-03-02 07:00 | 2016-03-02 07:30 |  |  |  | 2016-03-02 07:00 | 2016-03-02 07:30 | 30min |  | start no earlier than 2016-03-02 07:00 |  |  |  |  |  |  |
| 95 | 9.1.32 | 32 | manual | 30min | 2016-03-03 07:00 | 2016-03-03 07:30 |  |  |  | 2016-03-03 07:00 | 2016-03-03 07:30 | 30min |  | start no earlier than 2016-03-03 07:00 |  |  |  |  |  |  |
| 96 | 9.1.33 | 33 | manual | 30min | 2016-03-04 07:00 | 2016-03-04 07:30 |  |  |  | 2016-03-04 07:00 | 2016-03-04 07:30 | 30min |  | start no earlier than 2016-03-04 07:00 |  |  |  |  |  |  |
| 97 | 9.1.34 | 34 | manual | 30min | 2016-03-05 07:00 | 2016-03-05 07:30 |  |  |  | 2016-03-05 07:00 | 2016-03-05 07:30 | 30min |  | start no earlier than 2016-03-05 07:00 |  |  |  |  |  |  |
| 98 | 9.1.35 | 35 | manual | 30min | 2016-03-06 07:00 | 2016-03-06 07:30 |  |  |  | 2016-03-06 07:00 | 2016-03-06 07:30 | 30min |  | start no earlier than 2016-03-06 07:00 |  |  |  |  |  |  |
| 99 | 9.1.36 | 36 | manual | 30min | 2016-03-07 07:00 | 2016-03-07 07:30 |  |  |  | 2016-03-07 07:00 | 2016-03-07 07:30 | 30min |  | start no earlier than 2016-03-07 07:00 |  |  |  |  |  |  |
| 100 | 9.1.37 | 37 | manual | 30min | 2016-03-08 07:00 | 2016-03-08 07:30 |  |  |  | 2016-03-08 07:00 | 2016-03-08 07:30 | 30min |  | start no earlier than 2016-03-08 07:00 |  |  |  |  |  |  |
| 101 | 9.1.38 | 38 | manual | 30min | 2016-03-09 07:00 | 2016-03-09 07:30 |  |  |  | 2016-03-09 07:00 | 2016-03-09 07:30 | 30min |  | start no earlier than 2016-03-09 07:00 |  |  |  |  |  |  |
| 102 | 9.1.39 | 39 | manual | 30min | 2016-03-10 07:00 | 2016-03-10 07:30 |  |  |  | 2016-03-10 07:00 | 2016-03-10 07:30 | 30min |  | start no earlier than 2016-03-10 07:00 |  |  |  |  |  |  |
| 103 | 9.1.40 | 40 | manual | 30min | 2016-03-11 07:00 | 2016-03-11 07:30 |  |  |  | 2016-03-11 07:00 | 2016-03-11 07:30 | 30min |  | start no earlier than 2016-03-11 07:00 |  |  |  |  |  |  |
| 104 | 9.1.41 | 41 | manual | 30min | 2016-03-12 07:00 | 2016-03-12 07:30 |  |  |  | 2016-03-12 07:00 | 2016-03-12 07:30 | 30min |  | start no earlier than 2016-03-12 07:00 |  |  |  |  |  |  |
| 105 | 9.1.42 | 42 | manual | 30min | 2016-03-13 07:00 | 2016-03-13 07:30 |  |  |  | 2016-03-13 07:00 | 2016-03-13 07:30 | 30min |  | start no earlier than 2016-03-13 07:00 |  |  |  |  |  |  |
| 106 | 9.1.43 | 43 | manual | 30min | 2016-03-14 07:00 | 2016-03-14 07:30 |  |  |  | 2016-03-14 07:00 | 2016-03-14 07:30 | 30min |  | start no earlier than 2016-03-14 07:00 |  |  |  |  |  |  |
| 107 | 9.1.44 | 44 | manual | 30min | 2016-03-15 07:00 | 2016-03-15 07:30 |  |  |  | 2016-03-15 07:00 | 2016-03-15 07:30 | 30min |  | start no earlier than 2016-03-15 07:00 |  |  |  |  |  |  |
| 108 | 9.1.45 | 45 | manual | 30min | 2016-03-16 07:00 | 2016-03-16 07:30 |  |  |  | 2016-03-16 07:00 | 2016-03-16 07:30 | 30min |  | start no earlier than 2016-03-16 07:00 |  |  |  |  |  |  |
| 109 | 9.1.46 | 46 | manual | 30min | 2016-03-17 07:00 | 2016-03-17 07:30 |  |  |  | 2016-03-17 07:00 | 2016-03-17 07:30 | 30min |  | start no earlier than 2016-03-17 07:00 |  |  |  |  |  |  |
| 110 | 9.1.47 | 47 | manual | 30min | 2016-03-18 07:00 | 2016-03-18 07:30 |  |  |  | 2016-03-18 07:00 | 2016-03-18 07:30 | 30min |  | start no earlier than 2016-03-18 07:00 |  |  |  |  |  |  |
| 111 | 9.1.48 | 48 | manual | 30min | 2016-03-19 07:00 | 2016-03-19 07:30 |  |  |  | 2016-03-19 07:00 | 2016-03-19 07:30 | 30min |  | start no earlier than 2016-03-19 07:00 |  |  |  |  |  |  |
| 112 | 9.1.49 | 49 | manual | 30min | 2016-03-20 07:00 | 2016-03-20 07:30 |  |  |  | 2016-03-20 07:00 | 2016-03-20 07:30 | 30min |  | start no earlier than 2016-03-20 07:00 |  |  |  |  |  |  |
| 113 | 9.1.50 | 50 | manual | 30min | 2016-03-21 07:00 | 2016-03-21 07:30 |  |  |  | 2016-03-21 07:00 | 2016-03-21 07:30 | 30min |  | start no earlier than 2016-03-21 07:00 |  |  |  |  |  |  |
| 114 | 9.1.51 | 51 | manual | 30min | 2016-03-22 07:00 | 2016-03-22 07:30 |  |  |  | 2016-03-22 07:00 | 2016-03-22 07:30 | 30min |  | start no earlier than 2016-03-22 07:00 |  |  |  |  |  |  |
| 115 | 9.1.52 | 52 | manual | 30min | 2016-03-23 07:00 | 2016-03-23 07:30 |  |  |  | 2016-03-23 07:00 | 2016-03-23 07:30 | 30min |  | start no earlier than 2016-03-23 07:00 |  |  |  |  |  |  |
| 116 | 9.1.53 | 53 | manual | 30min | 2016-03-24 07:00 | 2016-03-24 07:30 |  |  |  | 2016-03-24 07:00 | 2016-03-24 07:30 | 30min |  | start no earlier than 2016-03-24 07:00 |  |  |  |  |  |  |
| 117 | 9.1.54 | 54 | manual | 30min | 2016-03-25 07:00 | 2016-03-25 07:30 |  |  |  | 2016-03-25 07:00 | 2016-03-25 07:30 | 30min |  | start no earlier than 2016-03-25 07:00 |  |  |  |  |  |  |
| 118 | 9.1.55 | 55 | manual | 30min | 2016-03-26 07:00 | 2016-03-26 07:30 |  |  |  | 2016-03-26 07:00 | 2016-03-26 07:30 | 30min |  | start no earlier than 2016-03-26 07:00 |  |  |  |  |  |  |
| 119 | 9.1.56 | 56 | manual | 30min | 2016-03-27 07:00 | 2016-03-27 07:30 |  |  |  | 2016-03-27 07:00 | 2016-03-27 07:30 | 30min |  | start no earlier than 2016-03-27 07:00 |  |  |  |  |  |  |
| 120 | 9.1.57 | 57 | manual | 30min | 2016-03-28 07:00 | 2016-03-28 07:30 |  |  |  | 2016-03-28 07:00 | 2016-03-28 07:30 | 30min |  | start no earlier than 2016-03-28 07:00 |  |  |  |  |  |  |
| 121 | 9.1.58 | 58 | manual | 30min | 2016-03-29 07:00 | 2016-03-29 07:30 |  |  |  | 2016-03-29 07:00 | 2016-03-29 07:30 | 30min |  | start no earlier than 2016-03-29 07:00 |  |  |  |  |  |  |
| 122 | 9.1.59 | 59 | manual | 30min | 2016-03-30 07:00 | 2016-03-30 07:30 |  |  |  | 2016-03-30 07:00 | 2016-03-30 07:30 | 30min |  | start no earlier than 2016-03-30 07:00 |  |  |  |  |  |  |
| 123 | 9.1.60 | 60 | manual | 30min | 2016-03-31 07:00 | 2016-03-31 07:30 |  |  |  | 2016-03-31 07:00 | 2016-03-31 07:30 | 30min |  | start no earlier than 2016-03-31 07:00 |  |  |  |  |  |  |
| 124 | 9.1.61 | 61 | manual | 30min | 2016-04-01 07:00 | 2016-04-01 07:30 |  |  |  | 2016-04-01 07:00 | 2016-04-01 07:30 | 30min |  | start no earlier than 2016-04-01 07:00 |  |  |  |  |  |  |

| ID | WBS | Task | Type | Duration | Start | Finish | Baseline start | Baseline finish | Baseline duration | Constraint |
| --- | --- | --- | --- | --- | --- | --- | --- | --- | --- | --- |
| 125 | 9.1.62 | 62 | manual | 30min | 2016-04-02 07:00 | 2016-04-02 07:30 | 2016-04-02 07:00 | 2016-04-02 07:30 | 30min | start no earlier than 2016-04-02 07:00 |
| 126 | 9.1.63 | 63 | manual | 30min | 2016-04-03 07:00 | 2016-04-03 07:30 | 2016-04-03 07:00 | 2016-04-03 07:30 | 30min | start no earlier than 2016-04-03 07:00 |
| 127 | 9.1.64 | 64 | manual | 30min | 2016-04-04 07:00 | 2016-04-04 07:30 | 2016-04-04 07:00 | 2016-04-04 07:30 | 30min | start no earlier than 2016-04-04 07:00 |
| 128 | 9.1.65 | 65 | manual | 30min | 2016-04-05 07:00 | 2016-04-05 07:30 | 2016-04-05 07:00 | 2016-04-05 07:30 | 30min | start no earlier than 2016-04-05 07:00 |
| 129 | 9.1.66 | 66 | manual | 30min | 2016-04-06 07:00 | 2016-04-06 07:30 | 2016-04-06 07:00 | 2016-04-06 07:30 | 30min | start no earlier than 2016-04-06 07:00 |
| 130 | 9.1.67 | 67 | manual | 30min | 2016-04-07 07:00 | 2016-04-07 07:30 | 2016-04-07 07:00 | 2016-04-07 07:30 | 30min | start no earlier than 2016-04-07 07:00 |
| 131 | 9.1.68 | 68 | manual | 30min | 2016-04-08 07:00 | 2016-04-08 07:30 | 2016-04-08 07:00 | 2016-04-08 07:30 | 30min | start no earlier than 2016-04-08 07:00 |
| 132 | 9.1.69 | 69 | manual | 30min | 2016-04-09 07:00 | 2016-04-09 07:30 | 2016-04-09 07:00 | 2016-04-09 07:30 | 30min | start no earlier than 2016-04-09 07:00 |
| 133 | 9.1.70 | 70 | manual | 30min | 2016-04-10 07:00 | 2016-04-10 07:30 | 2016-04-10 07:00 | 2016-04-10 07:30 | 30min | start no earlier than 2016-04-10 07:00 |
| 134 | 9.1.71 | 71 | manual | 30min | 2016-04-11 07:00 | 2016-04-11 07:30 | 2016-04-11 07:00 | 2016-04-11 07:30 | 30min | start no earlier than 2016-04-11 07:00 |
| 135 | 9.1.72 | 72 | manual | 30min | 2016-04-12 07:00 | 2016-04-12 07:30 | 2016-04-12 07:00 | 2016-04-12 07:30 | 30min | start no earlier than 2016-04-12 07:00 |
| 136 | 9.1.73 | 73 | manual | 30min | 2016-04-13 07:00 | 2016-04-13 07:30 | 2016-04-13 07:00 | 2016-04-13 07:30 | 30min | start no earlier than 2016-04-13 07:00 |
| 137 | 9.1.74 | 74 | manual | 30min | 2016-04-14 07:00 | 2016-04-14 07:30 | 2016-04-14 07:00 | 2016-04-14 07:30 | 30min | start no earlier than 2016-04-14 07:00 |
| 138 | 9.1.75 | 75 | manual | 30min | 2016-04-15 07:00 | 2016-04-15 07:30 | 2016-04-15 07:00 | 2016-04-15 07:30 | 30min | start no earlier than 2016-04-15 07:00 |
| 139 | 9.1.76 | 76 | manual | 30min | 2016-04-16 07:00 | 2016-04-16 07:30 | 2016-04-16 07:00 | 2016-04-16 07:30 | 30min | start no earlier than 2016-04-16 07:00 |
| 140 | 9.1.77 | 77 | manual | 30min | 2016-04-17 07:00 | 2016-04-17 07:30 | 2016-04-17 07:00 | 2016-04-17 07:30 | 30min | start no earlier than 2016-04-17 07:00 |
| 141 | 9.1.78 | 78 | manual | 30min | 2016-04-18 07:00 | 2016-04-18 07:30 | 2016-04-18 07:00 | 2016-04-18 07:30 | 30min | start no earlier than 2016-04-18 07:00 |
| 142 | 9.1.79 | 79 | manual | 30min | 2016-04-19 07:00 | 2016-04-19 07:30 | 2016-04-19 07:00 | 2016-04-19 07:30 | 30min | start no earlier than 2016-04-19 07:00 |
| 143 | 9.1.80 | 80 | manual | 30min | 2016-04-20 07:00 | 2016-04-20 07:30 | 2016-04-20 07:00 | 2016-04-20 07:30 | 30min | start no earlier than 2016-04-20 07:00 |
| 144 | 9.1.81 | 81 | manual | 30min | 2016-04-21 07:00 | 2016-04-21 07:30 | 2016-04-21 07:00 | 2016-04-21 07:30 | 30min | start no earlier than 2016-04-21 07:00 |
| 145 | 9.1.82 | 82 | manual | 30min | 2016-04-22 07:00 | 2016-04-22 07:30 | 2016-04-22 07:00 | 2016-04-22 07:30 | 30min | start no earlier than 2016-04-22 07:00 |
| 146 | 9.1.83 | 83 | manual | 30min | 2016-04-23 07:00 | 2016-04-23 07:30 | 2016-04-23 07:00 | 2016-04-23 07:30 | 30min | start no earlier than 2016-04-23 07:00 |
| 147 | 9.1.84 | 84 | manual | 30min | 2016-04-24 07:00 | 2016-04-24 07:30 | 2016-04-24 07:00 | 2016-04-24 07:30 | 30min | start no earlier than 2016-04-24 07:00 |
| 148 | 9.1.85 | 85 | manual | 30min | 2016-04-25 07:00 | 2016-04-25 07:30 | 2016-04-25 07:00 | 2016-04-25 07:30 | 30min | start no earlier than 2016-04-25 07:00 |
| 149 | 9.1.86 | 86 | manual | 30min | 2016-04-26 07:00 | 2016-04-26 07:30 | 2016-04-26 07:00 | 2016-04-26 07:30 | 30min | start no earlier than 2016-04-26 07:00 |
| 150 | 9.1.87 | 87 | manual | 30min | 2016-04-27 07:00 | 2016-04-27 07:30 | 2016-04-27 07:00 | 2016-04-27 07:30 | 30min | start no earlier than 2016-04-27 07:00 |
| 151 | 9.1.88 | 88 | manual | 30min | 2016-04-28 07:00 | 2016-04-28 07:30 | 2016-04-28 07:00 | 2016-04-28 07:30 | 30min | start no earlier than 2016-04-28 07:00 |
| 152 | 9.1.89 | 89 | manual | 30min | 2016-04-29 07:00 | 2016-04-29 07:30 | 2016-04-29 07:00 | 2016-04-29 07:30 | 30min | start no earlier than 2016-04-29 07:00 |
| 153 | 9.1.90 | 90 | manual | 30min | 2016-04-30 07:00 | 2016-04-30 07:30 | 2016-04-30 07:00 | 2016-04-30 07:30 | 30min | start no earlier than 2016-04-30 07:00 |
| 154 | 9.1.91 | 91 | manual | 30min | 2016-05-01 07:00 | 2016-05-01 07:30 | 2016-05-01 07:00 | 2016-05-01 07:30 | 30min | start no earlier than 2016-05-01 07:00 |
| 155 | 9.1.92 | 92 | manual | 30min | 2016-05-02 07:00 | 2016-05-02 07:30 | 2016-05-02 07:00 | 2016-05-02 07:30 | 30min | start no earlier than 2016-05-02 07:00 |
| 156 | 9.1.93 | 93 | manual | 30min | 2016-05-03 07:00 | 2016-05-03 07:30 | 2016-05-03 07:00 | 2016-05-03 07:30 | 30min | start no earlier than 2016-05-03 07:00 |
| 157 | 9.1.94 | 94 | manual | 30min | 2016-05-04 07:00 | 2016-05-04 07:30 | 2016-05-04 07:00 | 2016-05-04 07:30 | 30min | start no earlier than 2016-05-04 07:00 |
| 158 | 9.1.95 | 95 | manual | 30min | 2016-05-05 07:00 | 2016-05-05 07:30 | 2016-05-05 07:00 | 2016-05-05 07:30 | 30min | start no earlier than 2016-05-05 07:00 |
| 159 | 9.1.96 | 96 | manual | 30min | 2016-05-06 07:00 | 2016-05-06 07:30 | 2016-05-06 07:00 | 2016-05-06 07:30 | 30min | start no earlier than 2016-05-06 07:00 |
| 160 | 9.1.97 | 97 | manual | 30min | 2016-05-07 07:00 | 2016-05-07 07:30 | 2016-05-07 07:00 | 2016-05-07 07:30 | 30min | start no earlier than 2016-05-07 07:00 |
| 161 | 9.1.98 | 98 | manual | 30min | 2016-05-08 07:00 | 2016-05-08 07:30 | 2016-05-08 07:00 | 2016-05-08 07:30 | 30min | start no earlier than 2016-05-08 07:00 |
| 162 | 9.1.99 | 99 | manual | 30min | 2016-05-09 07:00 | 2016-05-09 07:30 | 2016-05-09 07:00 | 2016-05-09 07:30 | 30min | start no earlier than 2016-05-09 07:00 |
| 163 | 9.1.100 | 100 | manual | 30min | 2016-05-10 07:00 | 2016-05-10 07:30 | 2016-05-10 07:00 | 2016-05-10 07:30 | 30min | start no earlier than 2016-05-10 07:00 |
| 164 | 9.1.101 | 101 | manual | 30min | 2016-05-11 07:00 | 2016-05-11 07:30 | 2016-05-11 07:00 | 2016-05-11 07:30 | 30min | start no earlier than 2016-05-11 07:00 |
| 165 | 9.1.102 | 102 | manual | 30min | 2016-05-12 07:00 | 2016-05-12 07:30 | 2016-05-12 07:00 | 2016-05-12 07:30 | 30min | start no earlier than 2016-05-12 07:00 |
| 166 | 9.1.103 | 103 | manual | 30min | 2016-05-13 07:00 | 2016-05-13 07:30 | 2016-05-13 07:00 | 2016-05-13 07:30 | 30min | start no earlier than 2016-05-13 07:00 |
| 167 | 9.1.104 | 104 | manual | 30min | 2016-05-14 07:00 | 2016-05-14 07:30 | 2016-05-14 07:00 | 2016-05-14 07:30 | 30min | start no earlier than 2016-05-14 07:00 |
| 168 | 9.1.105 | 105 | manual | 30min | 2016-05-15 07:00 | 2016-05-15 07:30 | 2016-05-15 07:00 | 2016-05-15 07:30 | 30min | start no earlier than 2016-05-15 07:00 |
| 169 | 9.1.106 | 106 | manual | 30min | 2016-05-16 07:00 | 2016-05-16 07:30 | 2016-05-16 07:00 | 2016-05-16 07:30 | 30min | start no earlier than 2016-05-16 07:00 |
| 170 | 9.1.107 | 107 | manual | 30min | 2016-05-17 07:00 | 2016-05-17 07:30 | 2016-05-17 07:00 | 2016-05-17 07:30 | 30min | start no earlier than 2016-05-17 07:00 |
| 171 | 9.1.108 | 108 | manual | 30min | 2016-05-18 07:00 | 2016-05-18 07:30 | 2016-05-18 07:00 | 2016-05-18 07:30 | 30min | start no earlier than 2016-05-18 07:00 |
| 172 | 9.1.109 | 109 | manual | 30min | 2016-05-19 07:00 | 2016-05-19 07:30 | 2016-05-19 07:00 | 2016-05-19 07:30 | 30min | start no earlier than 2016-05-19 07:00 |
| 173 | 9.1.110 | 110 | manual | 30min | 2016-05-20 07:00 | 2016-05-20 07:30 | 2016-05-20 07:00 | 2016-05-20 07:30 | 30min | start no earlier than 2016-05-20 07:00 |
| 174 | 9.1.111 | 111 | manual | 30min | 2016-05-21 07:00 | 2016-05-21 07:30 | 2016-05-21 07:00 | 2016-05-21 07:30 | 30min | start no earlier than 2016-05-21 07:00 |
| 175 | 9.1.112 | 112 | manual | 30min | 2016-05-22 07:00 | 2016-05-22 07:30 | 2016-05-22 07:00 | 2016-05-22 07:30 | 30min | start no earlier than 2016-05-22 07:00 |
| 176 | 9.1.113 | 113 | manual | 30min | 2016-05-23 07:00 | 2016-05-23 07:30 | 2016-05-23 07:00 | 2016-05-23 07:30 | 30min | start no earlier than 2016-05-23 07:00 |
| 177 | 9.1.114 | 114 | manual | 30min | 2016-05-24 07:00 | 2016-05-24 07:30 | 2016-05-24 07:00 | 2016-05-24 07:30 | 30min | start no earlier than 2016-05-24 07:00 |
| 178 | 9.1.115 | 115 | manual | 30min | 2016-05-25 07:00 | 2016-05-25 07:30 | 2016-05-25 07:00 | 2016-05-25 07:30 | 30min | start no earlier than 2016-05-25 07:00 |
| 179 | 9.1.116 | 116 | manual | 30min | 2016-05-26 07:00 | 2016-05-26 07:30 | 2016-05-26 07:00 | 2016-05-26 07:30 | 30min | start no earlier than 2016-05-26 07:00 |
| 180 | 9.1.117 | 117 | manual | 30min | 2016-05-27 07:00 | 2016-05-27 07:30 | 2016-05-27 07:00 | 2016-05-27 07:30 | 30min | start no earlier than 2016-05-27 07:00 |
| 181 | 9.1.118 | 118 | manual | 30min | 2016-05-28 07:00 | 2016-05-28 07:30 | 2016-05-28 07:00 | 2016-05-28 07:30 | 30min | start no earlier than 2016-05-28 07:00 |
| 182 | 9.1.119 | 119 | manual | 30min | 2016-05-29 07:00 | 2016-05-29 07:30 | 2016-05-29 07:00 | 2016-05-29 07:30 | 30min | start no earlier than 2016-05-29 07:00 |
| 183 | 9.1.120 | 120 | manual | 30min | 2016-05-30 07:00 | 2016-05-30 07:30 | 2016-05-30 07:00 | 2016-05-30 07:30 | 30min | start no earlier than 2016-05-30 07:00 |
| 184 | 9.1.121 | 121 | manual | 30min | 2016-05-31 07:00 | 2016-05-31 07:30 | 2016-05-31 07:00 | 2016-05-31 07:30 | 30min | start no earlier than 2016-05-31 07:00 |
| 185 | 9.1.122 | 122 | manual | 30min | 2016-06-01 07:00 | 2016-06-01 07:30 | 2016-06-01 07:00 | 2016-06-01 07:30 | 30min | start no earlier than 2016-06-01 07:00 |
| 186 | 9.1.123 | 123 | manual | 30min | 2016-06-02 07:00 | 2016-06-02 07:30 | 2016-06-02 07:00 | 2016-06-02 07:30 | 30min | start no earlier than 2016-06-02 07:00 |
| 187 | 9.1.124 | 124 | manual | 30min | 2016-06-03 07:00 | 2016-06-03 07:30 | 2016-06-03 07:00 | 2016-06-03 07:30 | 30min | start no earlier than 2016-06-03 07:00 |
| 188 | 9.1.125 | 125 | manual | 30min | 2016-06-04 07:00 | 2016-06-04 07:30 | 2016-06-04 07:00 | 2016-06-04 07:30 | 30min | start no earlier than 2016-06-04 07:00 |
| 189 | 9.1.126 | 126 | manual | 30min | 2016-06-05 07:00 | 2016-06-05 07:30 | 2016-06-05 07:00 | 2016-06-05 07:30 | 30min | start no earlier than 2016-06-05 07:00 |
| 190 | 9.1.127 | 127 | manual | 30min | 2016-06-06 07:00 | 2016-06-06 07:30 | 2016-06-06 07:00 | 2016-06-06 07:30 | 30min | start no earlier than 2016-06-06 07:00 |
| 191 | 9.1.128 | 128 | manual | 30min | 2016-06-07 07:00 | 2016-06-07 07:30 | 2016-06-07 07:00 | 2016-06-07 07:30 | 30min | start no earlier than 2016-06-07 07:00 |
| 192 | 9.1.129 | 129 | manual | 30min | 2016-06-08 07:00 | 2016-06-08 07:30 | 2016-06-08 07:00 | 2016-06-08 07:30 | 30min | start no earlier than 2016-06-08 07:00 |
| 193 | 9.1.130 | 130 | manual | 30min | 2016-06-09 07:00 | 2016-06-09 07:30 | 2016-06-09 07:00 | 2016-06-09 07:30 | 30min | start no earlier than 2016-06-09 07:00 |
| 194 | 9.1.131 | 131 | manual | 30min | 2016-06-10 07:00 | 2016-06-10 07:30 | 2016-06-10 07:00 | 2016-06-10 07:30 | 30min | start no earlier than 2016-06-10 07:00 |

| ID | WBS | Task | Type | Duration | Start | Finish | Baseline start | Baseline finish | Baseline duration | Constraint |
| --- | --- | --- | --- | --- | --- | --- | --- | --- | --- | --- |
| 195 | 9.1.132 | 132 | manual | 30min | 2016-06-11 07:00 | 2016-06-11 07:30 | 2016-06-11 07:00 | 2016-06-11 07:30 | 30min | start no earlier than 2016-06-11 07:00 |
| 196 | 9.1.133 | 133 | manual | 30min | 2016-06-12 07:00 | 2016-06-12 07:30 | 2016-06-12 07:00 | 2016-06-12 07:30 | 30min | start no earlier than 2016-06-12 07:00 |
| 197 | 9.1.134 | 134 | manual | 30min | 2016-06-13 07:00 | 2016-06-13 07:30 | 2016-06-13 07:00 | 2016-06-13 07:30 | 30min | start no earlier than 2016-06-13 07:00 |
| 198 | 9.1.135 | 135 | manual | 30min | 2016-06-14 07:00 | 2016-06-14 07:30 | 2016-06-14 07:00 | 2016-06-14 07:30 | 30min | start no earlier than 2016-06-14 07:00 |
| 199 | 9.1.136 | 136 | manual | 30min | 2016-06-15 07:00 | 2016-06-15 07:30 | 2016-06-15 07:00 | 2016-06-15 07:30 | 30min | start no earlier than 2016-06-15 07:00 |
| 200 | 9.1.137 | 137 | manual | 30min | 2016-06-16 07:00 | 2016-06-16 07:30 | 2016-06-16 07:00 | 2016-06-16 07:30 | 30min | start no earlier than 2016-06-16 07:00 |
| 201 | 9.1.138 | 138 | manual | 30min | 2016-06-17 07:00 | 2016-06-17 07:30 | 2016-06-17 07:00 | 2016-06-17 07:30 | 30min | start no earlier than 2016-06-17 07:00 |
| 202 | 9.1.139 | 139 | manual | 30min | 2016-06-18 07:00 | 2016-06-18 07:30 | 2016-06-18 07:00 | 2016-06-18 07:30 | 30min | start no earlier than 2016-06-18 07:00 |
| 203 | 9.1.140 | 140 | manual | 30min | 2016-06-19 07:00 | 2016-06-19 07:30 | 2016-06-19 07:00 | 2016-06-19 07:30 | 30min | start no earlier than 2016-06-19 07:00 |
| 204 | 9.1.141 | 141 | manual | 30min | 2016-06-20 07:00 | 2016-06-20 07:30 | 2016-06-20 07:00 | 2016-06-20 07:30 | 30min | start no earlier than 2016-06-20 07:00 |
| 205 | 9.1.142 | 142 | manual | 30min | 2016-06-21 07:00 | 2016-06-21 07:30 | 2016-06-21 07:00 | 2016-06-21 07:30 | 30min | start no earlier than 2016-06-21 07:00 |
| 206 | 9.1.143 | 143 | manual | 30min | 2016-06-22 07:00 | 2016-06-22 07:30 | 2016-06-22 07:00 | 2016-06-22 07:30 | 30min | start no earlier than 2016-06-22 07:00 |
| 207 | 9.1.144 | 144 | manual | 30min | 2016-06-23 07:00 | 2016-06-23 07:30 | 2016-06-23 07:00 | 2016-06-23 07:30 | 30min | start no earlier than 2016-06-23 07:00 |
| 208 | 9.1.145 | 145 | manual | 30min | 2016-06-24 07:00 | 2016-06-24 07:30 | 2016-06-24 07:00 | 2016-06-24 07:30 | 30min | start no earlier than 2016-06-24 07:00 |
| 209 | 9.1.146 | 146 | manual | 30min | 2016-06-25 07:00 | 2016-06-25 07:30 | 2016-06-25 07:00 | 2016-06-25 07:30 | 30min | start no earlier than 2016-06-25 07:00 |
| 210 | 9.1.147 | 147 | manual | 30min | 2016-06-26 07:00 | 2016-06-26 07:30 | 2016-06-26 07:00 | 2016-06-26 07:30 | 30min | start no earlier than 2016-06-26 07:00 |
| 211 | 9.1.148 | 148 | manual | 30min | 2016-06-27 07:00 | 2016-06-27 07:30 | 2016-06-27 07:00 | 2016-06-27 07:30 | 30min | start no earlier than 2016-06-27 07:00 |
| 212 | 9.1.149 | 149 | manual | 30min | 2016-06-28 07:00 | 2016-06-28 07:30 | 2016-06-28 07:00 | 2016-06-28 07:30 | 30min | start no earlier than 2016-06-28 07:00 |
| 213 | 9.1.150 | 150 | manual | 30min | 2016-06-29 07:00 | 2016-06-29 07:30 | 2016-06-29 07:00 | 2016-06-29 07:30 | 30min | start no earlier than 2016-06-29 07:00 |
| 214 | 9.1.151 | 151 | manual | 30min | 2016-06-30 07:00 | 2016-06-30 07:30 | 2016-06-30 07:00 | 2016-06-30 07:30 | 30min | start no earlier than 2016-06-30 07:00 |
| 215 | 9.1.152 | 152 | manual | 30min | 2016-07-01 07:00 | 2016-07-01 07:30 | 2016-07-01 07:00 | 2016-07-01 07:30 | 30min | start no earlier than 2016-07-01 07:00 |
| 216 | 9.1.153 | 153 | manual | 30min | 2016-07-02 07:00 | 2016-07-02 07:30 | 2016-07-02 07:00 | 2016-07-02 07:30 | 30min | start no earlier than 2016-07-02 07:00 |
| 217 | 9.1.154 | 154 | manual | 30min | 2016-07-03 07:00 | 2016-07-03 07:30 | 2016-07-03 07:00 | 2016-07-03 07:30 | 30min | start no earlier than 2016-07-03 07:00 |
| 218 | 9.1.155 | 155 | manual | 30min | 2016-07-04 07:00 | 2016-07-04 07:30 | 2016-07-04 07:00 | 2016-07-04 07:30 | 30min | start no earlier than 2016-07-04 07:00 |
| 219 | 9.1.156 | 156 | manual | 30min | 2016-07-05 07:00 | 2016-07-05 07:30 | 2016-07-05 07:00 | 2016-07-05 07:30 | 30min | start no earlier than 2016-07-05 07:00 |
| 220 | 9.1.157 | 157 | manual | 30min | 2016-07-06 07:00 | 2016-07-06 07:30 | 2016-07-06 07:00 | 2016-07-06 07:30 | 30min | start no earlier than 2016-07-06 07:00 |
| 221 | 9.1.158 | 158 | manual | 30min | 2016-07-07 07:00 | 2016-07-07 07:30 | 2016-07-07 07:00 | 2016-07-07 07:30 | 30min | start no earlier than 2016-07-07 07:00 |
| 222 | 9.1.159 | 159 | manual | 30min | 2016-07-08 07:00 | 2016-07-08 07:30 | 2016-07-08 07:00 | 2016-07-08 07:30 | 30min | start no earlier than 2016-07-08 07:00 |
| 223 | 9.1.160 | 160 | manual | 30min | 2016-07-09 07:00 | 2016-07-09 07:30 | 2016-07-09 07:00 | 2016-07-09 07:30 | 30min | start no earlier than 2016-07-09 07:00 |
| 224 | 9.1.161 | 161 | manual | 30min | 2016-07-10 07:00 | 2016-07-10 07:30 | 2016-07-10 07:00 | 2016-07-10 07:30 | 30min | start no earlier than 2016-07-10 07:00 |
| 225 | 9.1.162 | 162 | manual | 30min | 2016-07-11 07:00 | 2016-07-11 07:30 | 2016-07-11 07:00 | 2016-07-11 07:30 | 30min | start no earlier than 2016-07-11 07:00 |
| 226 | 9.1.163 | 163 | manual | 30min | 2016-07-12 07:00 | 2016-07-12 07:30 | 2016-07-12 07:00 | 2016-07-12 07:30 | 30min | start no earlier than 2016-07-12 07:00 |
| 227 | 9.1.164 | 164 | manual | 30min | 2016-07-13 07:00 | 2016-07-13 07:30 | 2016-07-13 07:00 | 2016-07-13 07:30 | 30min | start no earlier than 2016-07-13 07:00 |
| 228 | 9.1.165 | 165 | manual | 30min | 2016-07-14 07:00 | 2016-07-14 07:30 | 2016-07-14 07:00 | 2016-07-14 07:30 | 30min | start no earlier than 2016-07-14 07:00 |
| 229 | 9.1.166 | 166 | manual | 30min | 2016-07-15 07:00 | 2016-07-15 07:30 | 2016-07-15 07:00 | 2016-07-15 07:30 | 30min | start no earlier than 2016-07-15 07:00 |
| 230 | 9.1.167 | 167 | manual | 30min | 2016-07-16 07:00 | 2016-07-16 07:30 | 2016-07-16 07:00 | 2016-07-16 07:30 | 30min | start no earlier than 2016-07-16 07:00 |
| 231 | 9.1.168 | 168 | manual | 30min | 2016-07-17 07:00 | 2016-07-17 07:30 | 2016-07-17 07:00 | 2016-07-17 07:30 | 30min | start no earlier than 2016-07-17 07:00 |
| 232 | 9.1.169 | 169 | manual | 30min | 2016-07-18 07:00 | 2016-07-18 07:30 | 2016-07-18 07:00 | 2016-07-18 07:30 | 30min | start no earlier than 2016-07-18 07:00 |
| 233 | 9.1.170 | 170 | manual | 30min | 2016-07-19 07:00 | 2016-07-19 07:30 | 2016-07-19 07:00 | 2016-07-19 07:30 | 30min | start no earlier than 2016-07-19 07:00 |
| 234 | 9.1.171 | 171 | manual | 30min | 2016-07-20 07:00 | 2016-07-20 07:30 | 2016-07-20 07:00 | 2016-07-20 07:30 | 30min | start no earlier than 2016-07-20 07:00 |
| 235 | 9.1.172 | 172 | manual | 30min | 2016-07-21 07:00 | 2016-07-21 07:30 | 2016-07-21 07:00 | 2016-07-21 07:30 | 30min | start no earlier than 2016-07-21 07:00 |
| 236 | 9.1.173 | 173 | manual | 30min | 2016-07-22 07:00 | 2016-07-22 07:30 | 2016-07-22 07:00 | 2016-07-22 07:30 | 30min | start no earlier than 2016-07-22 07:00 |
| 237 | 9.1.174 | 174 | manual | 30min | 2016-07-23 07:00 | 2016-07-23 07:30 | 2016-07-23 07:00 | 2016-07-23 07:30 | 30min | start no earlier than 2016-07-23 07:00 |
| 238 | 9.1.175 | 175 | manual | 30min | 2016-07-24 07:00 | 2016-07-24 07:30 | 2016-07-24 07:00 | 2016-07-24 07:30 | 30min | start no earlier than 2016-07-24 07:00 |
| 239 | 9.1.176 | 176 | manual | 30min | 2016-07-25 07:00 | 2016-07-25 07:30 | 2016-07-25 07:00 | 2016-07-25 07:30 | 30min | start no earlier than 2016-07-25 07:00 |
| 240 | 9.1.177 | 177 | manual | 30min | 2016-07-26 07:00 | 2016-07-26 07:30 | 2016-07-26 07:00 | 2016-07-26 07:30 | 30min | start no earlier than 2016-07-26 07:00 |
| 241 | 9.1.178 | 178 | manual | 30min | 2016-07-27 07:00 | 2016-07-27 07:30 | 2016-07-27 07:00 | 2016-07-27 07:30 | 30min | start no earlier than 2016-07-27 07:00 |
| 242 | 9.1.179 | 179 | manual | 30min | 2016-07-28 07:00 | 2016-07-28 07:30 | 2016-07-28 07:00 | 2016-07-28 07:30 | 30min | start no earlier than 2016-07-28 07:00 |
| 243 | 9.1.180 | 180 | manual | 30min | 2016-07-29 07:00 | 2016-07-29 07:30 | 2016-07-29 07:00 | 2016-07-29 07:30 | 30min | start no earlier than 2016-07-29 07:00 |
| 244 | 9.1.181 | 181 | manual | 30min | 2016-07-30 07:00 | 2016-07-30 07:30 | 2016-07-30 07:00 | 2016-07-30 07:30 | 30min | start no earlier than 2016-07-30 07:00 |
| 245 | 9.1.182 | 182 | manual | 30min | 2016-07-31 07:00 | 2016-07-31 07:30 | 2016-07-31 07:00 | 2016-07-31 07:30 | 30min | start no earlier than 2016-07-31 07:00 |
| 246 | 9.1.183 | 183 | manual | 30min | 2016-08-01 07:00 | 2016-08-01 07:30 | 2016-08-01 07:00 | 2016-08-01 07:30 | 30min | start no earlier than 2016-08-01 07:00 |
| 247 | 9.1.184 | 184 | manual | 30min | 2016-08-02 07:00 | 2016-08-02 07:30 | 2016-08-02 07:00 | 2016-08-02 07:30 | 30min | start no earlier than 2016-08-02 07:00 |
| 248 | 9.1.185 | 185 | manual | 30min | 2016-08-03 07:00 | 2016-08-03 07:30 | 2016-08-03 07:00 | 2016-08-03 07:30 | 30min | start no earlier than 2016-08-03 07:00 |
| 249 | 9.1.186 | 186 | manual | 30min | 2016-08-04 07:00 | 2016-08-04 07:30 | 2016-08-04 07:00 | 2016-08-04 07:30 | 30min | start no earlier than 2016-08-04 07:00 |
| 250 | 9.1.187 | 187 | manual | 30min | 2016-08-05 07:00 | 2016-08-05 07:30 | 2016-08-05 07:00 | 2016-08-05 07:30 | 30min | start no earlier than 2016-08-05 07:00 |
| 251 | 9.1.188 | 188 | manual | 30min | 2016-08-06 07:00 | 2016-08-06 07:30 | 2016-08-06 07:00 | 2016-08-06 07:30 | 30min | start no earlier than 2016-08-06 07:00 |
| 252 | 9.1.189 | 189 | manual | 30min | 2016-08-07 07:00 | 2016-08-07 07:30 | 2016-08-07 07:00 | 2016-08-07 07:30 | 30min | start no earlier than 2016-08-07 07:00 |
| 253 | 9.1.190 | 190 | manual | 30min | 2016-08-08 07:00 | 2016-08-08 07:30 | 2016-08-08 07:00 | 2016-08-08 07:30 | 30min | start no earlier than 2016-08-08 07:00 |
| 254 | 9.1.191 | 191 | manual | 30min | 2016-08-09 07:00 | 2016-08-09 07:30 | 2016-08-09 07:00 | 2016-08-09 07:30 | 30min | start no earlier than 2016-08-09 07:00 |
| 255 | 9.1.192 | 192 | manual | 30min | 2016-08-10 07:00 | 2016-08-10 07:30 | 2016-08-10 07:00 | 2016-08-10 07:30 | 30min | start no earlier than 2016-08-10 07:00 |
| 256 | 9.1.193 | 193 | manual | 30min | 2016-08-11 07:00 | 2016-08-11 07:30 | 2016-08-11 07:00 | 2016-08-11 07:30 | 30min | start no earlier than 2016-08-11 07:00 |
| 257 | 9.1.194 | 194 | manual | 30min | 2016-08-12 07:00 | 2016-08-12 07:30 | 2016-08-12 07:00 | 2016-08-12 07:30 | 30min | start no earlier than 2016-08-12 07:00 |
| 258 | 9.1.195 | 195 | manual | 30min | 2016-08-13 07:00 | 2016-08-13 07:30 | 2016-08-13 07:00 | 2016-08-13 07:30 | 30min | start no earlier than 2016-08-13 07:00 |
| 259 | 9.1.196 | 196 | manual | 30min | 2016-08-14 07:00 | 2016-08-14 07:30 | 2016-08-14 07:00 | 2016-08-14 07:30 | 30min | start no earlier than 2016-08-14 07:00 |
| 260 | 9.1.197 | 197 | manual | 30min | 2016-08-15 07:00 | 2016-08-15 07:30 | 2016-08-15 07:00 | 2016-08-15 07:30 | 30min | start no earlier than 2016-08-15 07:00 |
| 261 | 9.1.198 | 198 | manual | 30min | 2016-08-16 07:00 | 2016-08-16 07:30 | 2016-08-16 07:00 | 2016-08-16 07:30 | 30min | start no earlier than 2016-08-16 07:00 |
| 262 | 9.1.199 | 199 | manual | 30min | 2016-08-17 07:00 | 2016-08-17 07:30 | 2016-08-17 07:00 | 2016-08-17 07:30 | 30min | start no earlier than 2016-08-17 07:00 |
| 263 | 9.1.200 | 200 | manual | 30min | 2016-08-18 07:00 | 2016-08-18 07:30 | 2016-08-18 07:00 | 2016-08-18 07:30 | 30min | start no earlier than 2016-08-18 07:00 |
| 264 | 9.1.201 | 201 | manual | 30min | 2016-08-19 07:00 | 2016-08-19 07:30 | 2016-08-19 07:00 | 2016-08-19 07:30 | 30min | start no earlier than 2016-08-19 07:00 |

| ID | WBS | Task | Type | Duration | Start | Finish | Predecessors | Complete | Remaining | Baseline start | Baseline finish | Baseline duration | Total slack | Constraint | Resources | Work | Actual work | Cost | Baseline cost | Actual cost |
| --- | --- | --- | --- | --- | --- | --- | --- | --- | --- | --- | --- | --- | --- | --- | --- | --- | --- | --- | --- | --- |
| 265 | 9.1.202 | 202 | manual | 30min | 2016-08-20 07:00 | 2016-08-20 07:30 |  |  |  | 2016-08-20 07:00 | 2016-08-20 07:30 | 30min |  | start no earlier than 2016-08-20 07:00 |  |  |  |  |  |  |
| 266 | 9.1.203 | 203 | manual | 30min | 2016-08-21 07:00 | 2016-08-21 07:30 |  |  |  | 2016-08-21 07:00 | 2016-08-21 07:30 | 30min |  | start no earlier than 2016-08-21 07:00 |  |  |  |  |  |  |
| 267 | 9.1.204 | 204 | manual | 30min | 2016-08-22 07:00 | 2016-08-22 07:30 |  |  |  | 2016-08-22 07:00 | 2016-08-22 07:30 | 30min |  | start no earlier than 2016-08-22 07:00 |  |  |  |  |  |  |
| 268 | 9.1.205 | 205 | manual | 30min | 2016-08-23 07:00 | 2016-08-23 07:30 |  |  |  | 2016-08-23 07:00 | 2016-08-23 07:30 | 30min |  | start no earlier than 2016-08-23 07:00 |  |  |  |  |  |  |
| 269 | 9.1.206 | 206 | manual | 30min | 2016-08-24 07:00 | 2016-08-24 07:30 |  |  |  | 2016-08-24 07:00 | 2016-08-24 07:30 | 30min |  | start no earlier than 2016-08-24 07:00 |  |  |  |  |  |  |
| 270 | 9.1.207 | 207 | manual | 30min | 2016-08-25 07:00 | 2016-08-25 07:30 |  |  |  | 2016-08-25 07:00 | 2016-08-25 07:30 | 30min |  | start no earlier than 2016-08-25 07:00 |  |  |  |  |  |  |
| 271 | 9.1.208 | 208 | manual | 30min | 2016-08-26 07:00 | 2016-08-26 07:30 |  |  |  | 2016-08-26 07:00 | 2016-08-26 07:30 | 30min |  | start no earlier than 2016-08-26 07:00 |  |  |  |  |  |  |
| 272 | 9.1.209 | 209 | manual | 30min | 2016-08-27 07:00 | 2016-08-27 07:30 |  |  |  | 2016-08-27 07:00 | 2016-08-27 07:30 | 30min |  | start no earlier than 2016-08-27 07:00 |  |  |  |  |  |  |
| 273 | 9.1.210 | 210 | manual | 30min | 2016-08-28 07:00 | 2016-08-28 07:30 |  |  |  | 2016-08-28 07:00 | 2016-08-28 07:30 | 30min |  | start no earlier than 2016-08-28 07:00 |  |  |  |  |  |  |
| 274 | 9.1.211 | 211 | manual | 30min | 2016-08-29 07:00 | 2016-08-29 07:30 |  |  |  | 2016-08-29 07:00 | 2016-08-29 07:30 | 30min |  | start no earlier than 2016-08-29 07:00 |  |  |  |  |  |  |
| 275 | 9.1.212 | 212 | manual | 30min | 2016-08-30 07:00 | 2016-08-30 07:30 |  |  |  | 2016-08-30 07:00 | 2016-08-30 07:30 | 30min |  | start no earlier than 2016-08-30 07:00 |  |  |  |  |  |  |
| 276 | 9.1.213 | 213 | manual | 30min | 2016-08-31 07:00 | 2016-08-31 07:30 |  |  |  | 2016-08-31 07:00 | 2016-08-31 07:30 | 30min |  | start no earlier than 2016-08-31 07:00 |  |  |  |  |  |  |
| 277 | 9.1.214 | 214 | manual | 30min | 2016-09-01 07:00 | 2016-09-01 07:30 |  |  |  | 2016-09-01 07:00 | 2016-09-01 07:30 | 30min |  | start no earlier than 2016-09-01 07:00 |  |  |  |  |  |  |
| 278 | 9.1.215 | 215 | manual | 30min | 2016-09-02 07:00 | 2016-09-02 07:30 |  |  |  | 2016-09-02 07:00 | 2016-09-02 07:30 | 30min |  | start no earlier than 2016-09-02 07:00 |  |  |  |  |  |  |
| 279 | 9.1.216 | 216 | manual | 30min | 2016-09-03 07:00 | 2016-09-03 07:30 |  |  |  | 2016-09-03 07:00 | 2016-09-03 07:30 | 30min |  | start no earlier than 2016-09-03 07:00 |  |  |  |  |  |  |
| 280 | 9.1.217 | 217 | manual | 30min | 2016-09-04 07:00 | 2016-09-04 07:30 |  |  |  | 2016-09-04 07:00 | 2016-09-04 07:30 | 30min |  | start no earlier than 2016-09-04 07:00 |  |  |  |  |  |  |
| 281 | 9.1.218 | 218 | manual | 30min | 2016-09-05 07:00 | 2016-09-05 07:30 |  |  |  | 2016-09-05 07:00 | 2016-09-05 07:30 | 30min |  | start no earlier than 2016-09-05 07:00 |  |  |  |  |  |  |
| 282 | 9.1.219 | 219 | manual | 30min | 2016-09-06 07:00 | 2016-09-06 07:30 |  |  |  | 2016-09-06 07:00 | 2016-09-06 07:30 | 30min |  | start no earlier than 2016-09-06 07:00 |  |  |  |  |  |  |
| 283 | 9.1.220 | 220 | manual | 30min | 2016-09-07 07:00 | 2016-09-07 07:30 |  |  |  | 2016-09-07 07:00 | 2016-09-07 07:30 | 30min |  | start no earlier than 2016-09-07 07:00 |  |  |  |  |  |  |
| 284 | 9.1.221 | 221 | manual | 30min | 2016-09-08 07:00 | 2016-09-08 07:30 |  |  |  | 2016-09-08 07:00 | 2016-09-08 07:30 | 30min |  | start no earlier than 2016-09-08 07:00 |  |  |  |  |  |  |
| 285 | 9.1.222 | 222 | manual | 30min | 2016-09-09 07:00 | 2016-09-09 07:30 |  |  |  | 2016-09-09 07:00 | 2016-09-09 07:30 | 30min |  | start no earlier than 2016-09-09 07:00 |  |  |  |  |  |  |
| 286 | 9.2 | **Toma de datos** |  | 155d | 2016-02-01 07:00 A | 2016-09-05 08:00 | 63 | 9% | 140.47d | 2016-02-01 07:00 | 2016-09-12 08:00 | 160d | 0d |  | Matías | 1240h | 116.25h | 124,000 | 128,000 | 11,625 |
| 287 | 9.2.1 | Toma de datos 1 | manual | 1h | 2016-02-01 07:00 A | 2016-02-01 08:00 A |  | 100% |  | 2016-02-01 07:00 | 2016-02-01 08:00 | 1h |  | start no earlier than 2016-02-01 07:00 |  |  |  |  |  |  |
| 288 | 9.2.2 | Toma de datos 2 | manual | 1h | 2016-02-08 07:00 A | 2016-02-08 08:00 A |  | 100% |  | 2016-02-08 07:00 | 2016-02-08 08:00 | 1h |  | start no earlier than 2016-02-08 07:00 |  |  |  |  |  |  |
| 289 | 9.2.3 | Toma de datos 3 | manual | 1h | 2016-02-15 07:00 A | 2016-02-15 08:00 A |  | 100% |  | 2016-02-15 07:00 | 2016-02-15 08:00 | 1h |  | start no earlier than 2016-02-15 07:00 |  |  |  |  |  |  |
| 290 | 9.2.4 | Toma de datos 4 | manual | 1h | 2016-02-22 07:00 | 2016-02-22 08:00 |  |  |  | 2016-02-22 07:00 | 2016-02-22 08:00 | 1h |  | start no earlier than 2016-02-22 07:00 |  |  |  |  |  |  |
| 291 | 9.2.5 | Toma de datos 5 | manual | 1h | 2016-02-29 07:00 | 2016-02-29 08:00 |  |  |  | 2016-02-29 07:00 | 2016-02-29 08:00 | 1h |  | start no earlier than 2016-02-29 07:00 |  |  |  |  |  |  |
| 292 | 9.2.6 | Toma de datos 6 | manual | 1h | 2016-03-07 07:00 | 2016-03-07 08:00 |  |  |  | 2016-03-07 07:00 | 2016-03-07 08:00 | 1h |  | start no earlier than 2016-03-07 07:00 |  |  |  |  |  |  |
| 293 | 9.2.7 | Toma de datos 7 | manual | 1h | 2016-03-14 07:00 | 2016-03-14 08:00 |  |  |  | 2016-03-14 07:00 | 2016-03-14 08:00 | 1h |  | start no earlier than 2016-03-14 07:00 |  |  |  |  |  |  |
| 294 | 9.2.8 | Toma de datos 8 | manual | 1h | 2016-03-21 07:00 | 2016-03-21 08:00 |  |  |  | 2016-03-21 07:00 | 2016-03-21 08:00 | 1h |  | start no earlier than 2016-03-21 07:00 |  |  |  |  |  |  |
| 295 | 9.2.9 | Toma de datos 9 | manual | 1h | 2016-03-28 07:00 | 2016-03-28 08:00 |  |  |  | 2016-03-28 07:00 | 2016-03-28 08:00 | 1h |  | start no earlier than 2016-03-28 07:00 |  |  |  |  |  |  |
| 296 | 9.2.10 | Toma de datos 10 | manual | 1h | 2016-04-04 07:00 | 2016-04-04 08:00 |  |  |  | 2016-04-04 07:00 | 2016-04-04 08:00 | 1h |  | start no earlier than 2016-04-04 07:00 |  |  |  |  |  |  |
| 297 | 9.2.11 | Toma de datos 11 | manual | 1h | 2016-04-11 07:00 | 2016-04-11 08:00 |  |  |  | 2016-04-11 07:00 | 2016-04-11 08:00 | 1h |  | start no earlier than 2016-04-11 07:00 |  |  |  |  |  |  |
| 298 | 9.2.12 | Toma de datos 12 | manual | 1h | 2016-04-18 07:00 | 2016-04-18 08:00 |  |  |  | 2016-04-18 07:00 | 2016-04-18 08:00 | 1h |  | start no earlier than 2016-04-18 07:00 |  |  |  |  |  |  |
| 299 | 9.2.13 | Toma de datos 13 | manual | 1h | 2016-04-25 07:00 | 2016-04-25 08:00 |  |  |  | 2016-04-25 07:00 | 2016-04-25 08:00 | 1h |  | start no earlier than 2016-04-25 07:00 |  |  |  |  |  |  |
| 300 | 9.2.14 | Toma de datos 14 | manual | 1h | 2016-05-02 07:00 | 2016-05-02 08:00 |  |  |  | 2016-05-02 07:00 | 2016-05-02 08:00 | 1h |  | start no earlier than 2016-05-02 07:00 |  |  |  |  |  |  |
| 301 | 9.2.15 | Toma de datos 15 | manual | 1h | 2016-05-09 07:00 | 2016-05-09 08:00 |  |  |  | 2016-05-09 07:00 | 2016-05-09 08:00 | 1h |  | start no earlier than 2016-05-09 07:00 |  |  |  |  |  |  |
| 302 | 9.2.16 | Toma de datos 16 | manual | 1h | 2016-05-16 07:00 | 2016-05-16 08:00 |  |  |  | 2016-05-16 07:00 | 2016-05-16 08:00 | 1h |  | start no earlier than 2016-05-16 07:00 |  |  |  |  |  |  |
| 303 | 9.2.17 | Toma de datos 17 | manual | 1h | 2016-05-23 07:00 | 2016-05-23 08:00 |  |  |  | 2016-05-23 07:00 | 2016-05-23 08:00 | 1h |  | start no earlier than 2016-05-23 07:00 |  |  |  |  |  |  |
| 304 | 9.2.18 | Toma de datos 18 | manual | 1h | 2016-05-30 07:00 | 2016-05-30 08:00 |  |  |  | 2016-05-30 07:00 | 2016-05-30 08:00 | 1h |  | start no earlier than 2016-05-30 07:00 |  |  |  |  |  |  |
| 305 | 9.2.19 | Toma de datos 19 | manual | 1h | 2016-06-06 07:00 | 2016-06-06 08:00 |  |  |  | 2016-06-06 07:00 | 2016-06-06 08:00 | 1h |  | start no earlier than 2016-06-06 07:00 |  |  |  |  |  |  |
| 306 | 9.2.20 | Toma de datos 20 | manual | 1h | 2016-06-13 07:00 | 2016-06-13 08:00 |  |  |  | 2016-06-13 07:00 | 2016-06-13 08:00 | 1h |  | start no earlier than 2016-06-13 07:00 |  |  |  |  |  |  |
| 307 | 9.2.21 | Toma de datos 21 | manual | 1h | 2016-06-20 07:00 | 2016-06-20 08:00 |  |  |  | 2016-06-20 07:00 | 2016-06-20 08:00 | 1h |  | start no earlier than 2016-06-20 07:00 |  |  |  |  |  |  |
| 308 | 9.2.22 | Toma de datos 22 | manual | 1h | 2016-06-27 07:00 | 2016-06-27 08:00 |  |  |  | 2016-06-27 07:00 | 2016-06-27 08:00 | 1h |  | start no earlier than 2016-06-27 07:00 |  |  |  |  |  |  |
| 309 | 9.2.23 | Toma de datos 23 | manual | 1h | 2016-07-04 07:00 | 2016-07-04 08:00 |  |  |  | 2016-07-04 07:00 | 2016-07-04 08:00 | 1h |  | start no earlier than 2016-07-04 07:00 |  |  |  |  |  |  |
| 310 | 9.2.24 | Toma de datos 24 | manual | 1h | 2016-07-11 07:00 | 2016-07-11 08:00 |  |  |  | 2016-07-11 07:00 | 2016-07-11 08:00 | 1h |  | start no earlier than 2016-07-11 07:00 |  |  |  |  |  |  |
| 311 | 9.2.25 | Toma de datos 25 | manual | 1h | 2016-07-18 07:00 | 2016-07-18 08:00 |  |  |  | 2016-07-18 07:00 | 2016-07-18 08:00 | 1h |  | start no earlier than 2016-07-18 07:00 |  |  |  |  |  |  |
| 312 | 9.2.26 | Toma de datos 26 | manual | 1h | 2016-07-25 07:00 | 2016-07-25 08:00 |  |  |  | 2016-07-25 07:00 | 2016-07-25 08:00 | 1h |  | start no earlier than 2016-07-25 07:00 |  |  |  |  |  |  |
| 313 | 9.2.27 | Toma de datos 27 | manual | 1h | 2016-08-01 07:00 | 2016-08-01 08:00 |  |  |  | 2016-08-01 07:00 | 2016-08-01 08:00 | 1h |  | start no earlier than 2016-08-01 07:00 |  |  |  |  |  |  |
| 314 | 9.2.28 | Toma de datos 28 | manual | 1h | 2016-08-08 07:00 | 2016-08-08 08:00 |  |  |  | 2016-08-08 07:00 | 2016-08-08 08:00 | 1h |  | start no earlier than 2016-08-08 07:00 |  |  |  |  |  |  |
| 315 | 9.2.29 | Toma de datos 29 | manual | 1h | 2016-08-15 07:00 | 2016-08-15 08:00 |  |  |  | 2016-08-15 07:00 | 2016-08-15 08:00 | 1h |  | start no earlier than 2016-08-15 07:00 |  |  |  |  |  |  |
| 316 | 9.2.30 | Toma de datos 30 | manual | 1h | 2016-08-22 07:00 | 2016-08-22 08:00 |  |  |  | 2016-08-22 07:00 | 2016-08-22 08:00 | 1h |  | start no earlier than 2016-08-22 07:00 |  |  |  |  |  |  |
| 317 | 9.2.31 | Toma de datos 31 | manual | 1h | 2016-08-29 07:00 | 2016-08-29 08:00 |  |  |  | 2016-08-29 07:00 | 2016-08-29 08:00 | 1h |  | start no earlier than 2016-08-29 07:00 |  |  |  |  |  |  |
| 318 | 9.2.32 | Toma de datos 32 | manual | 1h | 2016-09-05 07:00 | 2016-09-05 08:00 |  |  |  | 2016-09-05 07:00 | 2016-09-05 08:00 | 1h |  | start no earlier than 2016-09-05 07:00 |  |  |  |  |  |  |

| ID | WBS | Task | Type | Duration | Start | Finish | Predecessors | Complete | Remaining | Baseline start | Baseline finish | Baseline duration | Total slack | Constraint | Resources | Work | Actual work | Cost | Baseline cost | Actual cost |
| --- | --- | --- | --- | --- | --- | --- | --- | --- | --- | --- | --- | --- | --- | --- | --- | --- | --- | --- | --- | --- |
| 319 | 9.3 | **Reunión de seguimiento** |  | 150d | 2016-02-05 07:00 A | 2016-09-02 09:00 | 286 | 13% | 131.25d | 2016-02-05 07:00 | 2016-09-02 09:00 | 150d | 0d |  | Matías | 1200h | 150h | 120,000 | 120,000 | 15,000 |
| 320 | 9.3.1 | Reunión de seguimiento 1 | manual | 2h | 2016-02-05 07:00 A | 2016-02-05 09:00 A |  | 100% |  | 2016-02-05 07:00 | 2016-02-05 09:00 | 2h |  | start no earlier than 2016-02-05 07:00 |  |  |  |  |  |  |
| 321 | 9.3.2 | Reunión de seguimiento 2 | manual | 2h | 2016-02-19 07:00 A | 2016-02-19 09:00 A |  | 100% |  | 2016-02-19 07:00 | 2016-02-19 09:00 | 2h |  | start no earlier than 2016-02-19 07:00 |  |  |  |  |  |  |
| 322 | 9.3.3 | Reunión de seguimiento 3 | manual | 2h | 2016-03-04 07:00 | 2016-03-04 09:00 |  |  |  | 2016-03-04 07:00 | 2016-03-04 09:00 | 2h |  | start no earlier than 2016-03-04 07:00 |  |  |  |  |  |  |
| 323 | 9.3.4 | Reunión de seguimiento 4 | manual | 2h | 2016-03-18 07:00 | 2016-03-18 09:00 |  |  |  | 2016-03-18 07:00 | 2016-03-18 09:00 | 2h |  | start no earlier than 2016-03-18 07:00 |  |  |  |  |  |  |
| 324 | 9.3.5 | Reunión de seguimiento 5 | manual | 2h | 2016-04-01 07:00 | 2016-04-01 09:00 |  |  |  | 2016-04-01 07:00 | 2016-04-01 09:00 | 2h |  | start no earlier than 2016-04-01 07:00 |  |  |  |  |  |  |
| 325 | 9.3.6 | Reunión de seguimiento 6 | manual | 2h | 2016-04-15 07:00 | 2016-04-15 09:00 |  |  |  | 2016-04-15 07:00 | 2016-04-15 09:00 | 2h |  | start no earlier than 2016-04-15 07:00 |  |  |  |  |  |  |
| 326 | 9.3.7 | Reunión de seguimiento 7 | manual | 2h | 2016-04-29 07:00 | 2016-04-29 09:00 |  |  |  | 2016-04-29 07:00 | 2016-04-29 09:00 | 2h |  | start no earlier than 2016-04-29 07:00 |  |  |  |  |  |  |
| 327 | 9.3.8 | Reunión de seguimiento 8 | manual | 2h | 2016-05-13 07:00 | 2016-05-13 09:00 |  |  |  | 2016-05-13 07:00 | 2016-05-13 09:00 | 2h |  | start no earlier than 2016-05-13 07:00 |  |  |  |  |  |  |
| 328 | 9.3.9 | Reunión de seguimiento 9 | manual | 2h | 2016-05-27 07:00 | 2016-05-27 09:00 |  |  |  | 2016-05-27 07:00 | 2016-05-27 09:00 | 2h |  | start no earlier than 2016-05-27 07:00 |  |  |  |  |  |  |
| 329 | 9.3.10 | Reunión de seguimiento 10 | manual | 2h | 2016-06-10 07:00 | 2016-06-10 09:00 |  |  |  | 2016-06-10 07:00 | 2016-06-10 09:00 | 2h |  | start no earlier than 2016-06-10 07:00 |  |  |  |  |  |  |
| 330 | 9.3.11 | Reunión de seguimiento 11 | manual | 2h | 2016-06-24 07:00 | 2016-06-24 09:00 |  |  |  | 2016-06-24 07:00 | 2016-06-24 09:00 | 2h |  | start no earlier than 2016-06-24 07:00 |  |  |  |  |  |  |
| 331 | 9.3.12 | Reunión de seguimiento 12 | manual | 2h | 2016-07-08 07:00 | 2016-07-08 09:00 |  |  |  | 2016-07-08 07:00 | 2016-07-08 09:00 | 2h |  | start no earlier than 2016-07-08 07:00 |  |  |  |  |  |  |
| 332 | 9.3.13 | Reunión de seguimiento 13 | manual | 2h | 2016-07-22 07:00 | 2016-07-22 09:00 |  |  |  | 2016-07-22 07:00 | 2016-07-22 09:00 | 2h |  | start no earlier than 2016-07-22 07:00 |  |  |  |  |  |  |
| 333 | 9.3.14 | Reunión de seguimiento 14 | manual | 2h | 2016-08-05 07:00 | 2016-08-05 09:00 |  |  |  | 2016-08-05 07:00 | 2016-08-05 09:00 | 2h |  | start no earlier than 2016-08-05 07:00 |  |  |  |  |  |  |
| 334 | 9.3.15 | Reunión de seguimiento 15 | manual | 2h | 2016-08-19 07:00 | 2016-08-19 09:00 |  |  |  | 2016-08-19 07:00 | 2016-08-19 09:00 | 2h |  | start no earlier than 2016-08-19 07:00 |  |  |  |  |  |  |
| 335 | 9.3.16 | Reunión de seguimiento 16 | manual | 2h | 2016-09-02 07:00 | 2016-09-02 09:00 |  |  |  | 2016-09-02 07:00 | 2016-09-02 09:00 | 2h |  | start no earlier than 2016-09-02 07:00 |  |  |  |  |  |  |
| 336 | 9.4 | **Estado de la compañia** |  | 0d | 2016-06-06 07:00 | 2016-06-06 09:00 | 319 |  |  | 2016-06-06 07:00 | 2016-06-06 09:00 |  | 0d |  | Matías |  |  |  |  |  |
| 337 | 9.4.1 | Estado de la compañia 1 | manual | 2h | 2016-06-06 07:00 | 2016-06-06 09:00 |  |  |  | 2016-06-06 07:00 | 2016-06-06 09:00 | 2h |  | start no earlier than 2016-06-06 07:00 |  |  |  |  |  |  |
